# Schedule

Schedule from MS Project, 2011-06-01 to 2012-09-25.
MBARI

## Calendars

- Standard: Mon-Fri 08:00-12:00, 13:00-17:00; Sat-Sun off.

## Schedule

| ID | WBS | Task | Duration | Start | Finish | Predecessors | Total slack | Free slack | Constraint |
| --- | --- | --- | --- | --- | --- | --- | --- | --- | --- |
| 3 | 1 | Electrical Gen. at-sea test | 40d? | 2011-11-14 | 2012-01-06 |  | 187d |  | start no earlier than 2011-11-14 |
| 6 | 2 | Power Converter Design, build and test | 208d? | 2011-06-01 | 2012-03-16 |  | 127d | 95d | finish no earlier than 2012-03-16 |
| 7 | 3 | Preliminary Design | 128d? | 2011-06-01 | 2011-11-25 |  | 217d |  | finish no earlier than 2011-11-25 |
| 8 | 4 | Component Fabrication | 25d? | 2011-11-28 | 2011-12-30 |  | 192d |  | finish no earlier than 2011-12-30 |
| 9 | 5 | Lab Testing | 25d? | 2012-01-02 | 2012-02-03 |  | 167d |  | finish no earlier than 2012-02-03 |
| 10 | 6 | Integration for at-sea use | 24d? | 2012-02-06 | 2012-03-08 |  | 143d |  | finish no earlier than 2012-03-08 |
| 11 | 7 | Battery Charge Test at Sea | 5d? | 2012-03-12 | 2012-03-16 |  | 137d |  | finish no earlier than 2012-03-16 |
| 14 | 8 | Power Passthru Wiring Integration | 176d? | 2011-06-01 | 2012-02-01 |  | 164d | 42d | start no earlier than 2011-06-01 |
| 19 | 9 | Propulsion Testing | 55d? | 2012-04-02 | 2012-06-15 |  | 72d |  | finish no earlier than 2012-06-15 |
| 20 | 10 | System Design and Component Selection | 15d? | 2012-04-02 | 2012-04-23 |  | 112d |  | finish no earlier than 2012-04-23 |
| 21 | 11 | Fabrication | 15d? | 2012-04-23 | 2012-05-11 |  | 97d |  | start no earlier than 2012-04-23 |
| 22 | 12 | Integration and Test | 14d? | 2012-05-14 | 2012-05-31 |  | 83d |  | start no earlier than 2012-05-14 |
| 23 | 13 | Test Deployment | 11d? | 2012-06-01 | 2012-06-15 |  | 72d |  | start no earlier than 2012-05-31 |
| 25 | 14 | Two-Week Demonstration Deployment | 10d? | 2012-07-30 | 2012-08-10 | 11 | 32d |  | start no earlier than 2012-07-30 |
| 28 | 15 | Final Report Writing | 37d? | 2012-08-06 | 2012-09-25 |  | 0d |  | start no earlier than 2012-08-06 |
